# FSAM Project Plan

Schedule from MS Project, 2008-07-29 to 2009-04-09.

## Calendars

- Standard: Mon-Fri 08:00-12:00, 13:00-17:00; Sat-Sun off.

## Schedule

| ID | WBS | Task | Duration | Start | Finish | Predecessors | Total slack |
| --- | --- | --- | --- | --- | --- | --- | --- |
| 1 | 1 | **Federal Segment Architecture Methodology** | 183d | 2008-07-29 | 2009-04-09 |  | 0d |
| 2 | 1.1 | **Step 1: Determine Participants and Launch Project** | 30d | 2008-07-29 | 2008-09-08 |  | 0d |
| 3 | 1.1.1 | **1.1: Determine the Executive Sponsor** | 4d | 2008-07-29 | 2008-08-01 |  | 0d |
| 4 | 1.1.1.1 | 1.1.1: Identify the segment governance framework | 2d | 2008-07-29 | 2008-07-30 |  | 0d |
| 5 | 1.1.1.2 | 1.1.2: Communicate to Business Owners the role of the Executive Sponsor | 1d | 2008-07-31 | 2008-07-31 | 4 | 0d |
| 6 | 1.1.1.3 | 1.1.3: Determine the most appropriate executive to be Executive Sponsor | 1d | 2008-08-01 | 2008-08-01 | 5 | 0d |
| 7 | 1.1.2 | **1.2: Develop the Purpose Statement for the Segment** | 6d | 2008-08-04 | 2008-08-11 | 3 | 0d |
| 8 | 1.1.2.1 | 1.2.1: Discuss the business challenges facing each Business Owner | 2d | 2008-08-04 | 2008-08-05 | 3 | 0d |
| 9 | 1.1.2.2 | 1.2.2: Synthesize the common business challenges across the Business Owners | 2d | 2008-08-06 | 2008-08-07 | 8 | 0d |
| 10 | 1.1.2.3 | 1.2.3: Communicate how segment architecture could assist with common business challenges | 1d | 2008-08-08 | 2008-08-08 | 9 | 0d |
| 11 | 1.1.2.4 | 1.2.4: Formulate the purpose statement | 1d | 2008-08-11 | 2008-08-11 | 10 | 0d |
| 12 | 1.1.3 | **1.3: Solicit Core Team Members** | 8d | 2008-08-12 | 2008-08-21 | 7 | 0d |
| 13 | 1.1.3.1 | 1.3.1: Communicate to Business Owner(s) the role of the Core Team | 1d | 2008-08-12 | 2008-08-12 | 7 | 0d |
| 14 | 1.1.3.2 | 1.3.2: Determine personnel to be appointed to the Core Team | 5d | 2008-08-13 | 2008-08-19 | 13 | 0d |
| 15 | 1.1.3.3 | 1.3.3: Communicate appointments to the affected personnel | 1d | 2008-08-20 | 2008-08-20 | 14 | 0d |
| 16 | 1.1.3.4 | 1.3.4: Issue a memorandum to communicate the formation of the Core Team and the purpose statement | 1d | 2008-08-21 | 2008-08-21 | 15 | 0d |
| 17 | 1.1.4 | **1.4: Create Core Team Charter and Project Plan** | 5d | 2008-08-22 | 2008-08-28 | 12 | 0d |
| 18 | 1.1.4.1 | 1.4.1: Develop draft Core Team charter | 2d | 2008-08-22 | 2008-08-25 | 12 | 0d |
| 19 | 1.1.4.2 | 1.4.2: Create project plan for segment architecture development | 2d | 2008-08-26 | 2008-08-27 | 18 | 0d |
| 20 | 1.1.4.3 | 1.4.3: Review and approve Core Team charter, project plan, and governance | 1d | 2008-08-28 | 2008-08-28 | 19 | 0d |
| 21 | 1.1.5 | **1.5: Establish the Communications Strategy** | 7d | 2008-08-29 | 2008-09-08 | 17 | 0d |
| 22 | 1.1.5.1 | 1.5.1: Determine communications goals and objectives | 2d | 2008-08-29 | 2008-09-01 | 17 | 0d |
| 23 | 1.1.5.2 | 1.5.2: Identify audience groups and design themes and key messages | 2d | 2008-09-02 | 2008-09-03 | 22 | 0d |
| 24 | 1.1.5.3 | 1.5.3: Select tactical communications vehicles | 1d | 2008-09-04 | 2008-09-04 | 23 | 0d |
| 25 | 1.1.5.4 | 1.5.4: Implement project collaboration website | 2d | 2008-09-05 | 2008-09-08 | 24 | 0d |

| ID | WBS | Task | Duration | Start | Finish | Predecessors | Total slack |
| --- | --- | --- | --- | --- | --- | --- | --- |
| 26 | 1.2 | **Step 2: Develop the Segment Scope and Strategic Intent** | 23d | 2008-09-09 | 2008-10-09 | 2 | 0d |
| 27 | 1.2.1 | **2.1: Establish Segment Scope and Context** | 7d | 2008-09-09 | 2008-09-17 | 21 | 0d |
| 28 | 1.2.1.1 | 2.1.1: Review segment architecture development purpose statement | 1d | 2008-09-09 | 2008-09-09 | 21 | 0d |
| 29 | 1.2.1.2 | 2.1.2: Identify organization components | 2d | 2008-09-10 | 2008-09-11 | 28 | 0d |
| 30 | 1.2.1.3 | 2.1.3: Identify stakeholders | 2d | 2008-09-12 | 2008-09-15 | 29 | 0d |
| 31 | 1.2.1.4 | 2.1.4: Establish segment summary description | 1d | 2008-09-16 | 2008-09-16 | 30 | 0d |
| 32 | 1.2.1.5 | 2.1.5: Validate / approve segment scope and context | 1d | 2008-09-17 | 2008-09-17 | 31 | 0d |
| 33 | 1.2.1.6 | 2.1.6: Refine / update segment scope and context | 1d | 2008-09-09 | 2008-09-09 |  | 6d |
| 34 | 1.2.2 | **2.2: Identify and Prioritize Strategic Improvement Opportunities** | 5d | 2008-09-18 | 2008-09-24 | 27 | 0d |
| 35 | 1.2.2.1 | 2.1.1: Review segment scope and context | 1d | 2008-09-18 | 2008-09-18 | 27 | 0d |
| 36 | 1.2.2.2 | 2.1.2: Identify segment risks and impacts | 3d | 2008-09-19 | 2008-09-23 | 35 | 1d |
| 37 | 1.2.2.3 | 2.1.3: Identify performance gaps | 2d | 2008-09-19 | 2008-09-22 | 35 | 2d |
| 38 | 1.2.2.4 | 2.1.4: Formulate and prioritize business needs | 1d | 2008-09-19 | 2008-09-19 | 35 | 0d |
| 39 | 1.2.2.5 | 2.1.5: Formulate and prioritize strategic improvement opportunities | 2d | 2008-09-22 | 2008-09-23 | 38 | 0d |
| 40 | 1.2.2.6 | 2.1.6: Validate strategic improvement opportunities | 1d | 2008-09-24 | 2008-09-24 | 39 | 0d |
| 41 | 1.2.3 | **2.3: Define Strategic Intent** | 8d | 2008-09-25 | 2008-10-06 | 34 | 0d |
| 42 | 1.2.3.1 | 2.3.1: Describe segment target state vision | 3d | 2008-09-25 | 2008-09-29 | 34 | 0d |
| 43 | 1.2.3.2 | 2.3.2: Establish segment’s strategic performance | 2d | 2008-09-30 | 2008-10-01 | 42 | 0d |
| 44 | 1.2.3.3 | 2.3.3: Identify target maturity levels for common / mission services | 2d | 2008-10-02 | 2008-10-03 | 43 | 0d |
| 45 | 1.2.3.4 | 2.3.4: Document the strategic intent | 1d | 2008-10-06 | 2008-10-06 | 44 | 0d |
| 46 | 1.2.4 | **2.4: Validate and Communicate the Scope and Strategic Intent** | 3d | 2008-10-07 | 2008-10-09 | 41 | 0d |
| 47 | 1.2.4.1 | 2.4.1: Package scope and strategic intent | 2d | 2008-10-07 | 2008-10-08 | 41 | 0d |
| 48 | 1.2.4.2 | 2.4.2: Present scope and strategic intent for approval | 1d | 2008-10-09 | 2008-10-09 | 47 | 0d |
| 49 | 1.3 | **Step 3: Define Business and Information Requirements** | 29d | 2008-10-10 | 2008-11-19 | 26 | 0d |
| 50 | 1.3.1 | **3.1: Determine Current Business and Information Environment Associated with Strategic Improvement Opportunities** | 9d | 2008-10-10 | 2008-10-22 | 46 | 0d |
| 51 | 1.3.1.1 | 3.1.1: Determine the value chains for the common / mission services | 2d | 2008-10-10 | 2008-10-13 | 46 | 0d |
| 52 | 1.3.1.2 | 3.1.2: Define the business function model and associate it to the value chain | 1d | 2008-10-14 | 2008-10-14 | 51 | 0d |
| 53 | 1.3.1.3 | 3.1.3: Analyze existing IT investments that relate to the business processes | 1d | 2008-10-15 | 2008-10-15 | 52 | 0d |
| 54 | 1.3.1.4 | 3.1.4: Analyze processes and determine high-level information requirements including organizational relationships | 2d | 2008-10-16 | 2008-10-17 | 53 | 0d |
| 55 | 1.3.1.5 | 3.1.5: Assess current information sources | 3d | 2008-10-20 | 2008-10-22 | 54 | 0d |

| ID | WBS | Task | Duration | Start | Finish | Predecessors | Total slack |
| --- | --- | --- | --- | --- | --- | --- | --- |
| 56 | 1.3.2 | **3.2: Determine Business and Information Improvement Opportunities** | 7d | 2008-10-23 | 2008-10-31 | 50 | 0d |
| 57 | 1.3.2.1 | 3.2.1: Align strategic improvement opportunities to the business architecture | 2d | 2008-10-23 | 2008-10-24 | 50 | 0d |
| 58 | 1.3.2.2 | 3.2.2: Determine the required adjustments to the business architecture | 2d | 2008-10-27 | 2008-10-28 | 57 | 0d |
| 59 | 1.3.2.3 | 3.2.3: Align strategic improvement opportunities to the information architecture | 1d | 2008-10-29 | 2008-10-29 | 58 | 0d |
| 60 | 1.3.2.4 | 3.2.4: Determine the required adjustments to the information architecture | 2d | 2008-10-30 | 2008-10-31 | 59 | 0d |
| 61 | 1.3.3 | **3.3: Define Target Business and Information Architecture** | 10d | 2008-11-03 | 2008-11-14 | 56 | 0d |
| 62 | 1.3.3.1 | 3.3.1: Define target business processes and their performance including organizational relationships | 3d | 2008-11-03 | 2008-11-05 | 56 | 0d |
| 63 | 1.3.3.2 | 3.3.2: Define target data relationships and business data stewards | 3d | 2008-11-06 | 2008-11-10 | 62 | 0d |
| 64 | 1.3.3.3 | 3.3.3: Define the target information services | 2d | 2008-11-11 | 2008-11-12 | 63 | 0d |
| 65 | 1.3.3.4 | 3.3.4: Ensure target business and information architecture addresses strategic improvement opportunities | 2d | 2008-11-13 | 2008-11-14 | 64 | 0d |
| 66 | 1.3.4 | **3.4: Validate and Communicate Target Business and Information Architecture** | 3d | 2008-11-17 | 2008-11-19 | 61 | 0d |
| 67 | 1.3.4.1 | 3.4.1: Package the business and information architecture | 2d | 2008-11-17 | 2008-11-18 | 61 | 0d |
| 68 | 1.3.4.2 | 3.4.2: Present the business and information architecture for approval | 1d | 2008-11-19 | 2008-11-19 | 67 | 0d |
| 69 | 1.4 | **Step 4: Define the Conceptual Solution Architecture** | 34d | 2008-11-20 | 2009-01-06 | 49 | 0d |
| 70 | 1.4.1 | **4.1: Access Systems and Technology Environment for Alignment with Performance, Business and Information Requirements** | 14d | 2008-11-20 | 2008-12-09 | 66 | 0d |
| 71 | 1.4.1.1 | 4.1.1: Collect information on existing segment system and service capabilities | 3d | 2008-11-20 | 2008-11-24 | 66 | 0d |
| 72 | 1.4.1.2 | 4.1.2: Define the as-is conceptual solution architecture | 5d | 2008-11-25 | 2008-12-01 | 71 | 0d |
| 73 | 1.4.1.3 | 4.1.3: Assess business value and performance of systems and services | 3d | 2008-12-02 | 2008-12-04 | 72 | 0d |
| 74 | 1.4.1.4 | 4.1.4: Determine adjustments necessary to the as-is conceptual solution architecture | 3d | 2008-12-05 | 2008-12-09 | 73 | 0d |
| 75 | 1.4.2 | **4.2: Define the Target Conceptual Solutions Architecture** | 10d | 2008-12-10 | 2008-12-23 | 70 | 0d |
| 76 | 1.4.2.1 | 4.2.1: Identify service and solution reuse opportunities | 2d | 2008-12-10 | 2008-12-11 | 70 | 0d |
| 77 | 1.4.2.2 | 4.2.2: Define applicable high-level technology, service, and information standards | 2d | 2008-12-12 | 2008-12-15 | 76 | 0d |
| 78 | 1.4.2.3 | 4.2.3: Identify required target system and service components | 3d | 2008-12-16 | 2008-12-18 | 77 | 0d |
| 79 | 1.4.2.4 | 4.2.4: Define relationships between target systems and services | 3d | 2008-12-19 | 2008-12-23 | 78 | 0d |

| ID | WBS | Task | Duration | Start | Finish | Predecessors | Total slack |
| --- | --- | --- | --- | --- | --- | --- | --- |
| 80 | 1.4.3 | **4.3: Identify and Analyze Systems and Service Transition Dependencies** | 7d | 2008-12-24 | 2009-01-01 | 75 | 0d |
| 81 | 1.4.3.1 | 4.3.1: Identify and analyze alternatives for transition | 5d | 2008-12-24 | 2008-12-30 | 75 | 0d |
| 82 | 1.4.3.2 | 4.3.2: Develop recommendations outlining selected alternatives | 2d | 2008-12-31 | 2009-01-01 | 81 | 0d |
| 83 | 1.4.4 | **4.4: Validate and Communicate the Conceptual Solution Architecture** | 3d | 2009-01-02 | 2009-01-06 | 80 | 0d |
| 84 | 1.4.4.1 | 4.4.1: Package the conceptual solution architecture | 2d | 2009-01-02 | 2009-01-05 | 80 | 0d |
| 85 | 1.4.4.2 | 4.4.2: Present the conceptual solution architecture for approval | 1d | 2009-01-06 | 2009-01-06 | 84 | 0d |
| 86 | 1.5 | **Step 5: Author the Modernization Blueprint** | 67d | 2009-01-07 | 2009-04-09 |  | 0d |
| 87 | 1.5.1 | **5.1: Perform Cost/Value/Risk Analysis to Develop Implementation Recommendations** | 23d | 2009-01-07 | 2009-02-06 | 83 | 0d |
| 88 | 1.5.1.1 | 5.1.1: Identify findings | 5d | 2009-01-07 | 2009-01-13 | 83 | 0d |
| 89 | 1.5.1.2 | 5.1.2: Develop transition options | 5d | 2009-01-14 | 2009-01-20 | 88 | 0d |
| 90 | 1.5.1.3 | 5.1.3: Perform cost / value / risk analysis to compare transition options | 5d | 2009-01-21 | 2009-01-27 | 89 | 0d |
| 91 | 1.5.1.4 | 5.1.4: Develop prioritized implementation recommendations | 5d | 2009-01-28 | 2009-02-03 | 90 | 0d |
| 92 | 1.5.1.5 | 5.1.5: Develop lessons learned | 3d | 2009-02-04 | 2009-02-06 | 91 | 0d |
| 93 | 1.5.2 | **5.2: Develop Draft Blueprint and Sequencing Plan** | 20d | 2009-02-09 | 2009-03-06 | 87 | 0d |
| 94 | 1.5.2.1 | 5.2.1: Develop the draft work breakdown structure | 5d | 2009-02-09 | 2009-02-13 | 87 | 0d |
| 95 | 1.5.2.2 | 5.2.2: Develop the draft sequencing plan | 5d | 2009-02-16 | 2009-02-20 | 94 | 0d |
| 96 | 1.5.2.3 | 5.2.3: Develop the draft segment blueprint | 10d | 2009-02-23 | 2009-03-06 | 95 | 0d |
| 97 | 1.5.3 | **5.3: Review and Finalize the Blueprint and Sequencing Plan** | 21d | 2009-03-09 | 2009-04-06 | 93 | 0d |
| 98 | 1.5.3.1 | 5.3.1: Distribute the draft segment blueprint for review | 1d | 2009-03-09 | 2009-03-09 | 93 | 0d |
| 99 | 1.5.3.2 | 5.3.2: Collect comments | 15d | 2009-03-10 | 2009-03-30 | 98 | 0d |
| 100 | 1.5.3.3 | 5.3.3: Develop the final segment blueprint | 5d | 2009-03-31 | 2009-04-06 | 99 | 0d |
| 101 | 1.5.4 | **5.4: Brief Core Team and Obtain Approvals** | 3d | 2009-04-07 | 2009-04-09 | 97 | 0d |
| 102 | 1.5.4.1 | 5.4.1: Distribute final review materials | 1d | 2009-04-07 | 2009-04-07 | 97 | 0d |
| 103 | 1.5.4.2 | 5.4.2: Conduct review and obtain approval | 2d | 2009-04-08 | 2009-04-09 | 102 | 0d |
